# Издание номера журнала

Schedule from MS Project, 2002-01-10 to 2002-04-11, status date 2002-02-10, costs in $.
MS Project 2002
Анализ рисков в расписании. Определяем слишком короткие задачи.

## Calendars

- Standard: Mon-Thu 09:00-12:00, 13:00-18:00; Fri 08:00-12:00, 13:00-17:00; Sat-Sun off. Exceptions (off unless hours are given): 2002-02-25, 2002-03-08.

## Resources

| Resource | Group | Rate | Cost per use |
| --- | --- | --- | --- |
| Иванов | Редактор раздела | 6.25 |  |
| Бумага для типографии |  | 15 |  |
| Фотомодель по контракту | Фотомодель |  | 200 |
| Терехов | Оператор печатного аппарата | 2.5 |  |
| Тарарухин | Оператор печатного аппарата | 3.44 |  |
| Борисов | Оператор печатного аппарата | 3.12 |  |
| Семенов | Оператор Mac | 4.69 |  |
| Бурков | Оператор Mac | 3.12 |  |
| Лимонов | Оператор Mac | 5 |  |
| Улендеева | Верстальщик | 4.69 |  |
| Сергеева | Верстальщик | 3.75 |  |
| Жуков | Фотограф | 3.12 |  |
| Еремин | Дизайнер | 7.5 |  |
| Ураганов | Корректор | 500 |  |
| Баранов | Корректор | 500 |  |
| Козлов | Технический редактор | 800 |  |
| Васин | Технический редактор | 800 |  |
| Уваров | Главный редактор | 2000 |  |
| Галкина | Отвественный секретарь | 3.12 |  |
| Сидоров | Редактор раздела | 6.25 |  |
| Петров | Редактор раздела | 6.25 |  |
| Краска для вывода пленок |  | 100 |  |
| Фотопленка |  | 2 |  |
| Тарасова | Верстальщик | 3.75 |  |
| Авторы |  | 0.25 |  |

## Schedule

| ID | WBS | Task | Type | Duration | Start | Finish | Predecessors | Total slack | Free slack | Constraint | Resources | Work | Cost |
| --- | --- | --- | --- | --- | --- | --- | --- | --- | --- | --- | --- | --- | --- |
| 1 | МАЙ//001 | **Планирование номера** |  | 11.5d | 2002-01-10 | 2002-01-25 |  | -0.62d | 0d |  |  | 80.88h | 16,436.7 |
| 2 | МАЙ//001.A | Сбор предложений от авторов |  | 5d | 2002-01-10 | 2002-01-16 |  | -0.62d | 0d |  | Иванов [25%]; Петров [25%]; Сидоров [25%] | 15h | 93.75 |
| 3 | МАЙ//001.B | Подготовка плана номера |  | 3d | 2002-01-17 | 2002-01-21 | 2 | -0.62d | 0d |  | Иванов [25%]; Петров [25%]; Сидоров [25%]; Уваров [12.5%] | 20h | 4,112.5 |
| 4 | МАЙ//001.C | Предварительная редколлегия |  | 3h | 2002-01-22 | 2002-01-22 | 3 | -0.62d | 0d |  | Иванов; Петров; Сидоров; Галкина; Уваров | 15h | 6,065.62 |
| 5 | МАЙ//001.D | Доработка планов с учетом замечаний |  | 3d | 2002-01-22 | 2002-01-25 | 4 | -0.62d | 0d |  | Иванов; Петров; Сидоров | 18.88h | 117.96 |
| 6 | МАЙ//001.E | Редколлегия |  | 3h | 2002-01-25 | 2002-01-25 | 5 | -0.38d | 0d | start no later than 2002-01-25 | Иванов; Петров; Сидоров; Галкина; Уваров | 12h | 6,046.87 |
| 7 | МАЙ//001.F | План номера утвержден | milestone | 0d | 2002-01-25 | 2002-01-25 | 6FS-1h | -0.38d | 0d |  |  |  |  |
| 8 | МАЙ//002 | **Подготовка материалов** |  | 36d | 2002-01-25 | 2002-03-19 | 7 | 0d |  |  |  | 331.73h | 40,311.48 |
| 9 | МАЙ//002.A | **Подготовка обложки** |  | 30.88d | 2002-02-01 | 2002-03-19 |  | 0d |  |  |  | 88.27h | 543.3 |
| 10 | МАЙ//002.A-a | Отбор модели |  | 13.83h | 2002-02-01 | 2002-02-04 |  | 0d |  | must start on 2002-02-01 | Еремин [50%] | 6.92h | 51.87 |
| 11 | МАЙ//002.A-b | Фотосъемка модели |  | 3d | 2002-02-04 | 2002-02-07 | 10 | 24.15d | 23.15d |  | Жуков; Фотомодель по контракту; Фотопленка | 48h | 277 |
| 12 | МАЙ//002.A-c | Подготовка анонсов материалов номера для обложки |  | 3d | 2002-03-12 | 2002-03-14 | 22FS-5% | 1d | 0d | start no earlier than 2002-03-12 | Сидоров [49%] | 11.75h | 73.43 |
| 13 | МАЙ//002.A-d | Передача рекламных анонсов в предыдущий номер | milestone | 1d | 2002-03-01 | 2002-03-04 | 22FS-5% | 27.5d |  |  |  |  |  |
| 14 | МАЙ//002.A-e | Верстка обложки |  | 3d | 2002-03-15 | 2002-03-19 | 12, 11 | 1d | 0d |  | Еремин [70%]; Жуков [20%] | 21.6h | 141 |
| 15 | МАЙ//002.A-f | Обложка готова | milestone | 0d | 2002-03-19 | 2002-03-19 | 14 | 1d |  |  |  |  |  |
| 16 | МАЙ//002.B | **Подготовка текстов** |  | 29.13d | 2002-01-25 | 2002-03-11 |  | 0d |  |  |  | 243.47h | 39,768.18 |
| 17 | МАЙ//002.B-a | Подготовка редакционных заданий |  | 3.42d | 2002-01-25 | 2002-01-30 |  | -0.38d | 0d | start no later than 2002-01-25 | Иванов; Петров; Сидоров; Галкина | 73.09h | 405.8 |
| 18 | МАЙ//002.B-b | Рассылка заданий авторам |  | 1.34d | 2002-01-30 | 2002-02-01 | 17 | 6.87d | 0d |  | Галкина [33.3%] | 1.96h | 6.12 |
| 19 | МАЙ//002.B-c | Утверждение заданий авторами |  | 4d | 2002-02-01 | 2002-02-07 | 18 | 6.87d | 0d |  | Галкина [12.5%] | 4h | 12.5 |
| 20 | МАЙ//002.B-d | Статьи в работе у авторов | milestone | 0d | 2002-02-07 | 2002-02-07 | 19 | 6.87d | 0d |  |  |  |  |
| 21 | МАЙ//002.B-e | Статьи поступили в редакцию | milestone | 0d | 2002-02-21 | 2002-02-21 | 20FS+10d | 6.87d | 0d |  | Авторы |  | 1,000 |
| 22 | 002.B-f | **Редактирование материалов** |  | 10d | 2002-02-21 | 2002-03-11 | 21 | 6.87d | 0d |  |  | 84h | 525 |
| 23 | 2.2.6.1 | Редактирование раздела 1 |  | 10d | 2002-02-21 | 2002-03-11 |  | 6.87d |  |  | Иванов [70%] | 28h | 175 |
| 24 | 2.2.6.2 | Редактирование раздела 2 |  | 10d | 2002-02-21 | 2002-03-11 |  | 6.87d |  |  | Петров [70%] | 28h | 175 |
| 25 | 2.2.6.3 | Редактирование раздела 3 |  | 10d | 2002-02-21 | 2002-03-11 |  | 6.87d |  |  | Сидоров [70%] | 28h | 175 |
| 26 | МАЙ//002.B-g | Техническое редактирование |  | 4.17d | 2002-02-26 | 2002-03-04 | 22SS+2d | 0.08d | 0d |  | Иванов [30%]; Петров [30%]; Сидоров [30%]; Галкина [50%]; Васин; Козлов | 80.42h | 37,818.76 |
| 27 | МАЙ//002.B-h | Тексты готовы | milestone | 0d | 2002-03-04 | 2002-03-04 | 26 | 27.33d |  |  |  |  |  |
| 28 | МАЙ//002.C | Подготовка материалов завершена | milestone | 0d | 2002-03-04 | 2002-03-04 | 26 | 27.33d |  |  |  |  |  |

Notes:
- 2: Text1: Файл предложений в редакционном формате.
- 3: Text1: План номера в формате XLS с названиями статей от редакторов разделов.
- 4: Text1: Предварительный план номиера обсужден.
- 5: Text1: Планы каждого из редакторов разделов доработаны с учетом замечаний.
- 6: Задания на этот номер должны включать темы: / ·летний отдых; / ·фотокамеры; / ·видеокамеры. / Text1: Окончательный план номера согласован с редакторами разделов и главным редактором.
- 13: Шаблон документа для передачи анонсов.
- 17: Подготовить задания нужно за 3 дня!
- 19: Авторы должны уложиться в 2 дня!
- 22: Сокращено до 12 дней.

| ID | WBS | Task | Type | Duration | Start | Finish | Predecessors | Total slack | Free slack | Constraint | Resources | Work | Cost |
| --- | --- | --- | --- | --- | --- | --- | --- | --- | --- | --- | --- | --- | --- |
| 29 | МАЙ//003 | **Верстка журнала** |  | 14.87d | 2002-03-01 | 2002-03-22 |  | 0.08d |  |  |  | 351h | 42,956.25 |
| 30 | МАЙ//003.A | Обработка текста и иллюстраций |  | 10.17d | 2002-03-01 | 2002-03-18 | 26SS+3d | 0.08d | 0d |  | Тарасова [98.4%]; Улендеева [98.4%] | 160h | 675 |
| 31 | МАЙ//003.B | **Вычитка** |  | 5d | 2002-03-06 | 2002-03-14 | 30SS+3d | 20.5d | 0d |  |  | 80h | 40,000 |
| 32 | 3.2.1 | Вычитка1 |  | 5d | 2002-03-06 | 2002-03-14 |  | 20.5d |  |  | Ураганов | 40h | 20,000 |
| 33 | 3.2.2 | Вычитка1 |  | 5d | 2002-03-06 | 2002-03-14 |  | 20.5d |  |  | Баранов | 40h | 20,000 |
| 34 | МАЙ//003.C | **Сверка** |  | 5d | 2002-03-12 | 2002-03-19 | 31SS+3d | 3.87d |  |  |  | 100h | 625 |
| 35 | 3.3.1 | Сверка1 |  | 5d | 2002-03-12 | 2002-03-19 |  | 3.87d |  |  | Иванов | 40h | 250 |
| 36 | 3.3.2 | Сверка2 |  | 5d | 2002-03-12 | 2002-03-19 |  | 3.87d |  |  | Петров | 40h | 250 |
| 37 | 3.3.3 | Сверка3 |  | 4d | 2002-03-13 | 2002-03-18 |  | 4d |  | start no earlier than 2002-03-13 | Сидоров | 20h | 125 |
| 38 | МАЙ//003.D | Подготовка оглавления |  | 16h | 2002-03-18 | 2002-03-20 | 30 | 0d |  | finish no earlier than 2002-03-20 | Сидоров [50%] | 5h | 31.25 |
| 39 | МАЙ//003.E | Окончательная сборка |  | 2d | 2002-03-21 | 2002-03-22 | 38, 15 | 0d |  |  | Сидоров [25%]; Васин [25%] | 6h | 1,625 |
| 40 | МАЙ//003.F | Номер сверстан | milestone | 0d | 2002-03-22 | 2002-03-22 | 39, 34 | 0d |  |  |  |  |  |
| 41 | МАЙ//004 | **Предпечатная подготовка** |  | 13.63d | 2002-03-22 | 2002-04-11 | 40 | 0d |  |  |  | 325.14h | 1,319.31 |
| 42 | МАЙ//004.A | Конвертция сверстанного номера в формат Mac |  | 6.25d | 2002-03-22 | 2002-03-26 |  | 0d |  |  | Лимонов [76.9%]; Бурков [98.8%]; Семенов [76.9%] | 85.84h | 357.74 |
| 43 | МАЙ//004.B | Цветоделение |  | 10.67d | 2002-03-26 | 2002-04-04 | 42 | 0d |  |  | Бурков [20%]; Семенов [20%]; Борисов [25%]; Тарарухин [20%]; Терехов [20%]; Бумага для типографии | 57.4h | 208.02 |
| 44 | МАЙ//004.C | Коррекция |  | 6.92d | 2002-03-27 | 2002-03-31 | 43SS+1d | 0d |  |  | Лимонов [25%]; Бурков [25%]; Семенов [25%] | 41.5h | 177.23 |
| 45 | МАЙ//004.D | Вывод пленок |  | 15d | 2002-03-29 | 2002-04-11 | 44SS+2d | 0d |  |  | Лимонов [34.8%]; Бурков [34.8%]; Борисов [41.8%]; Тарарухин [41.8%]; Терехов [41.8%]; Краска для вывода пленок | 140.4h | 576.32 |
| 46 | МАЙ//004.E | Номер готов к передаче в типографию | milestone | 0d | 2002-04-11 | 2002-04-11 | 45 | 0d |  |  |  |  |  |
